# timeline2

Schedule from MS Project, 2003-08-02 to 2003-09-07.
mbari

## Calendars

- 24 Hours: Mon-Sun 00:00-24:00.

## Schedule

| ID | WBS | Task | Duration | Start | Finish | Predecessors | Total slack | Free slack | Constraint |
| --- | --- | --- | --- | --- | --- | --- | --- | --- | --- |
| 1 | 1 | **Modelling** | 7d | 2003-08-02 22:00 | 2003-08-05 06:00 |  | 100.25d |  |  |
| 2 | 1.1 | **ROMS Modelling** | 7d | 2003-08-02 22:00 | 2003-08-05 06:00 |  | 99.31d |  |  |
| 3 | 1.1.1 | ROMS Modelling 1 | 8h | 2003-08-02 22:00 | 2003-08-03 06:00 |  | 105.31d | 0.25d | start no earlier than 2003-08-02 22:00 |
| 4 | 1.1.2 | ROMS Modelling 2 | 8h | 2003-08-03 22:00 | 2003-08-04 06:00 |  | 102.31d | 0.25d | start no earlier than 2003-08-03 22:00 |
| 5 | 1.1.3 | ROMS Modelling 3 | 8h | 2003-08-04 22:00 | 2003-08-05 06:00 |  | 99.31d | 0.25d | start no earlier than 2003-08-04 22:00 |
| 6 | 1.2 | **HOPS Modelling Activity** | 3.69d | 2003-08-03 03:00 | 2003-08-04 08:30 |  | 102.69d |  |  |
| 7 | 1.2.1 | **Data Conversion** | 3.06d | 2003-08-03 03:00 | 2003-08-04 03:30 |  | 102.12d |  |  |
| 8 | 1.2.1.1 | Data Conversion 1 | 0.5h | 2003-08-03 03:00 | 2003-08-03 03:30 |  | 102.69d | 0d | start no earlier than 2003-08-03 03:00 |
| 9 | 1.2.1.2 | Data Conversion 1 | 0.5h | 2003-08-04 03:00 | 2003-08-04 03:30 |  | 102.12d | 0d | start no earlier than 2003-08-04 03:00 |
| 10 | 1.2.2 | **Data Quality Control** | 3.06d | 2003-08-03 03:30 | 2003-08-04 04:00 |  | 102.12d |  |  |
| 11 | 1.2.2.1 | Data QC 1 | 0.5h | 2003-08-03 03:30 | 2003-08-03 04:00 | 8 | 102.69d | 0d |  |
| 12 | 1.2.2.2 | Data QC 2 | 0.5h | 2003-08-04 03:30 | 2003-08-04 04:00 | 9 | 102.12d | 0d |  |
| 13 | 1.2.3 | **Objective Analysis** | 3.12d | 2003-08-03 04:00 | 2003-08-04 05:00 |  | 102.12d |  |  |
| 14 | 1.2.3.1 | OA 1 | 1h | 2003-08-03 04:00 | 2003-08-03 05:00 | 11 | 102.69d | 0d |  |
| 15 | 1.2.3.2 | OA 2 | 1h | 2003-08-04 04:00 | 2003-08-04 05:00 | 12 | 102.12d | 0d |  |
| 16 | 1.2.4 | **PE Initial** | 3.06d | 2003-08-03 05:00 | 2003-08-04 05:30 |  | 102.12d |  |  |
| 17 | 1.2.4.1 | PE Initial 1 | 0.5h | 2003-08-03 05:00 | 2003-08-03 05:30 | 14 | 102.69d | 0d |  |
| 18 | 1.2.4.2 | PE Initial 2 | 0.5h | 2003-08-04 05:00 | 2003-08-04 05:30 | 15 | 102.12d | 0d |  |
| 19 | 1.2.5 | **PE Forcing** | 3.06d | 2003-08-03 04:00 | 2003-08-04 04:30 |  | 102.25d |  |  |
| 20 | 1.2.5.1 | PE Forcing 1 | 0.5h | 2003-08-03 04:00 | 2003-08-03 04:30 | 11 | 102.81d | 0.12d |  |
| 21 | 1.2.5.2 | PE Forcing 2 | 0.5h | 2003-08-04 04:00 | 2003-08-04 04:30 | 12 | 102.25d | 0.12d |  |
| 22 | 1.2.6 | **PE Model** | 3.12d | 2003-08-03 05:30 | 2003-08-04 06:30 |  | 102.12d |  |  |
| 23 | 1.2.6.1 | PE Model 1 | 1h | 2003-08-03 05:30 | 2003-08-03 06:30 | 17, 20 | 102.69d | 0d |  |
| 24 | 1.2.6.2 | PE Model 2 | 1h | 2003-08-04 05:30 | 2003-08-04 06:30 | 18, 21 | 102.12d | 0d |  |

| ID | WBS | Task | Type | Duration | Start | Finish | Predecessors | Total slack | Free slack | Constraint |
| --- | --- | --- | --- | --- | --- | --- | --- | --- | --- | --- |
| 25 | 1.2.7 | **Model Quality Control** |  | 3.12d | 2003-08-03 06:30 | 2003-08-04 07:30 |  | 102.12d |  |  |
| 26 | 1.2.7.1 | Model QC 1 |  | 1h | 2003-08-03 06:30 | 2003-08-03 07:30 | 23 | 102.69d | 0d |  |
| 27 | 1.2.7.2 | Model QC 2 |  | 1h | 2003-08-04 06:30 | 2003-08-04 07:30 | 24 | 102.12d | 0d |  |
| 28 | 1.2.8 | **4D Fields** |  | 3d | 2003-08-03 07:30 | 2003-08-04 07:30 |  | 102.69d |  |  |
| 29 | 1.2.8.1 | 4DF 1 | milestone | 0h | 2003-08-03 07:30 | 2003-08-03 07:30 | 26 | 102.69d | 0d |  |
| 30 | 1.2.8.2 | 4DF 2 | milestone | 0h | 2003-08-04 07:30 | 2003-08-04 07:30 | 27 | 103.06d |  |  |
| 31 | 1.2.9 | **Graphical Products** |  | 3.12d | 2003-08-03 07:30 | 2003-08-04 08:30 |  | 102.94d |  |  |
| 32 | 1.2.9.1 | GP 1 |  | 1h | 2003-08-03 07:30 | 2003-08-03 08:30 | 26 | 105.94d | 0d |  |
| 33 | 1.2.9.2 | GP 2 |  | 1h | 2003-08-04 07:30 | 2003-08-04 08:30 | 27 | 102.94d | 0d |  |
| 34 | 1.2.10 | **Decision Aids to RTOC** |  | 3d | 2003-08-03 08:30 | 2003-08-04 08:30 |  | 102.94d |  |  |
| 35 | 1.2.10.1 | DA 1 | milestone | 0h | 2003-08-03 08:30 | 2003-08-03 08:30 | 32 | 105.94d |  |  |
| 36 | 1.2.10.2 | DA 2 | milestone | 0h | 2003-08-04 08:30 | 2003-08-04 08:30 | 33 | 102.94d |  |  |
| 37 | 2 | **ESSE Computation** |  | 3.38d | 2003-08-03 07:30 | 2003-08-04 10:30 |  | 102.69d |  |  |
| 38 | 2.1 | **ESSE Phys. Cycle 1** |  | 3.38d | 2003-08-03 07:30 | 2003-08-04 10:30 | 29 | 102.69d |  |  |
| 39 | 2.1.1 | **ESSE Forecast** |  | 3.12d | 2003-08-03 07:30 | 2003-08-04 08:30 |  | 102.69d | 0d |  |
| 40 | 2.1.1.1 | **Physical only** |  | 3.12d | 2003-08-03 07:30 | 2003-08-04 08:30 |  | 102.69d |  |  |
| 41 | 2.1.1.1.1 | Error Sim for Data Assimilation |  | 20h | 2003-08-03 07:30 | 2003-08-04 03:30 | 29 | 102.69d | 0d |  |
| 42 | 2.1.1.1.2 | error simulation for adaptive sample |  | 5h | 2003-08-04 03:30 | 2003-08-04 08:30 | 41 | 102.69d |  |  |
| 43 | 2.1.2 | ESSE Adaptive Sampling |  | 2h | 2003-08-04 08:30 | 2003-08-04 10:30 | 39 | 102.69d |  |  |
| 44 | 2.1.3 | **ESSE Assimilation/Min error Variance** |  | 0.25d | 2003-08-04 08:30 | 2003-08-04 10:30 | 39 | 102.69d |  |  |
| 45 | 2.1.3.1 | Physical Only |  | 2h | 2003-08-04 08:30 | 2003-08-04 10:30 |  | 102.69d |  |  |
| 46 | 2.1.4 | **ESSE Error Learning** |  | 0.12d | 2003-08-03 07:30 | 2003-08-03 08:30 |  | 105.94d |  |  |
| 47 | 2.1.4.1 | Physical Only |  | 1h | 2003-08-03 07:30 | 2003-08-03 08:30 |  | 105.94d |  |  |
| 48 | 3 | **Super Ensemble Computation** |  | 6.06d | 2003-08-03 08:00 | 2003-08-05 08:30 |  | 99.06d |  |  |
| 49 | 3.1 | Super Ensemble Computation 1 |  | 0.5h | 2003-08-03 08:00 | 2003-08-03 08:30 | 3, 26 | 105.06d | 0d | start no earlier than 2003-08-03 08:00 |
| 50 | 3.2 | Super Ensemble Computation 2 |  | 0.5h | 2003-08-04 08:00 | 2003-08-04 08:30 | 4, 27 | 102.06d | 0d | start no earlier than 2003-08-04 08:00 |
| 51 | 3.3 | Super Ensemble Computation 3 |  | 0.5h | 2003-08-05 08:00 | 2003-08-05 08:30 | 5 | 99.06d | 0d | start no earlier than 2003-08-05 08:00 |

| ID | WBS | Task | Type | Duration | Start | Finish | Predecessors | Baseline start | Baseline finish | Baseline duration | Total slack | Free slack | Constraint |
| --- | --- | --- | --- | --- | --- | --- | --- | --- | --- | --- | --- | --- | --- |
| 52 | 4 | **LCS Computation** |  | 6.38d | 2003-08-03 08:30 | 2003-08-05 11:30 |  |  |  |  | 99.06d |  |  |
| 53 | 4.1 | LCS Computation 1 |  | 3h | 2003-08-03 08:30 | 2003-08-03 11:30 | 49 |  |  |  | 105.06d | 0d | start no earlier than 2003-08-02 08:00 |
| 54 | 4.2 | LCS Computation 2 |  | 3h | 2003-08-04 08:30 | 2003-08-04 11:30 | 50 |  |  |  | 102.06d | 0d | start no earlier than 2003-08-03 08:00 |
| 55 | 4.3 | LCS Computation 3 |  | 3h | 2003-08-05 08:30 | 2003-08-05 11:30 | 51 |  |  |  | 99.06d | 0d | start no earlier than 2003-08-04 08:00 |
| 56 | 5 | **RTOC Deliberation** |  | 8.81d | 2003-08-03 11:30 | 2003-08-06 10:00 |  |  |  |  | 96.5d |  |  |
| 57 | 5.1 | RTOC Deliberation 1 |  | 2h | 2003-08-03 11:30 | 2003-08-03 13:30 | 53 |  |  |  | 105.06d | 0d | start no earlier than 2003-08-03 08:00 |
| 58 | 5.2 | RTOC Deliberation 2 |  | 2h | 2003-08-04 11:30 | 2003-08-04 13:30 | 54 |  |  |  | 102.06d | 0d | start no earlier than 2003-08-04 08:00 |
| 59 | 5.3 | RTOC Deliberation 3 |  | 2h | 2003-08-05 11:30 | 2003-08-05 13:30 | 55 |  |  |  | 99.06d | 0d | start no earlier than 2003-08-05 08:00 |
| 60 | 5.4 | RTOC Deliberation 4 |  | 2h | 2003-08-06 08:00 | 2003-08-06 10:00 |  |  |  |  | 96.5d | 0d | start no earlier than 2003-08-06 08:00 |
| 61 | 6 | **AS Vehicle Tasking** |  | 14.56d | 2003-08-03 13:30 | 2003-08-08 10:00 |  |  |  |  | 90.75d |  |  |
| 62 | 6.1 | AS Vehicle Tasking 1 |  | 2h | 2003-08-03 13:30 | 2003-08-03 15:30 | 57 |  |  |  | 105.06d |  | start no earlier than 2003-08-03 08:00 |
| 63 | 6.2 | AS Vehicle Tasking 2 |  | 2h | 2003-08-04 13:30 | 2003-08-04 15:30 | 58 |  |  |  | 102.06d |  | start no earlier than 2003-08-04 08:00 |
| 64 | 6.3 | AS Vehicle Tasking 3 |  | 2h | 2003-08-05 13:30 | 2003-08-05 15:30 | 59 |  |  |  | 99.06d |  | start no earlier than 2003-08-05 08:00 |
| 65 | 6.4 | AS Vehicle Tasking 4 |  | 2h | 2003-08-06 10:00 | 2003-08-06 12:00 | 60 |  |  |  | 96.5d |  | start no earlier than 2003-08-06 08:00 |
| 66 | 6.5 | AS Vehicle Tasking 5 |  | 2h | 2003-08-07 08:00 | 2003-08-07 10:00 |  |  |  |  | 93.75d |  | start no earlier than 2003-08-07 08:00 |
| 67 | 6.6 | AS Vehicle Tasking 6 |  | 2h | 2003-08-08 08:00 | 2003-08-08 10:00 |  |  |  |  | 90.75d |  | start no earlier than 2003-08-08 08:00 |
| 68 | 7 | **AS Glider Operations** |  | 9.76d | 2003-08-02 10:00 | 2003-08-05 16:05 |  |  |  |  | 98.99d |  |  |
| 69 | 7.1 | **AS Glider Data Surfacing** |  | 9.73d | 2003-08-02 10:00 | 2003-08-05 15:50 |  | 2003-07-14 10:10 | 2003-08-02 10:55 | 57.09d | 98.99d |  |  |
| 70 | 7.1.1 | AS Glider Surfacing 1 | milestone | 20min | 2003-08-02 10:00 | 2003-08-02 10:20 |  | 2003-08-02 08:00 | 2003-08-02 08:20 | 20min | 98.99d | 0d | start no earlier than 2003-08-02 10:00 |
| 71 | 7.1.2 | AS Observation Data QC1 |  | 5min | 2003-08-02 10:20 | 2003-08-02 10:25 | 70 | 2003-08-02 08:20 | 2003-08-02 08:25 | 5min | 98.99d | 0d |  |
| 72 | 7.1.3 | AS Feedback Control 1 |  | 10min | 2003-08-02 10:25 | 2003-08-02 10:35 | 71 |  |  |  | 98.99d | 0d |  |
| 73 | 7.1.4 | AS Glider Dive 1 | milestone | 0h | 2003-08-02 10:35 | 2003-08-02 10:35 | 72 | 2003-08-02 08:35 | 2003-08-02 08:35 | 0h | 98.99d | 0d |  |
| 74 | 7.1.5 | AS Glider Surfacing 2 | milestone | 20min | 2003-08-02 12:35 | 2003-08-02 12:55 | 73FS+2h |  |  |  | 98.99d | 0d |  |
| 75 | 7.1.6 | AS Observation Data QC2 |  | 5min | 2003-08-02 12:55 | 2003-08-02 13:00 | 74 |  |  |  | 98.99d | 0d |  |
| 76 | 7.1.7 | AS Feedback Control 2 |  | 10min | 2003-08-02 13:00 | 2003-08-02 13:10 | 75 |  |  |  | 98.99d | 0d |  |
| 77 | 7.1.8 | AS Glider Dive 2 | milestone | 0h | 2003-08-02 13:10 | 2003-08-02 13:10 | 76 |  |  |  | 98.99d | 0d |  |
| 78 | 7.1.9 | AS Glider Surfacing 3 | milestone | 20min | 2003-08-02 15:10 | 2003-08-02 15:30 | 77FS+2h |  |  |  | 98.99d | 0d |  |
| 79 | 7.1.10 | AS Observation Data QC3 |  | 5min | 2003-08-02 15:30 | 2003-08-02 15:35 | 78 |  |  |  | 98.99d | 0d |  |
| 80 | 7.1.11 | AS Feedback Control 2 |  | 10min | 2003-08-02 15:35 | 2003-08-02 15:45 | 79 |  |  |  | 98.99d | 0d |  |
| 81 | 7.1.12 | AS Glider Dive 2 | milestone | 0h | 2003-08-02 15:45 | 2003-08-02 15:45 | 80 |  |  |  | 98.99d | 0d |  |
| 82 | 7.1.13 | AS Glider Surfacing 4 | milestone | 20min | 2003-08-02 17:45 | 2003-08-02 18:05 | 81FS+2h |  |  |  | 98.99d | 0d |  |
| 83 | 7.1.14 | AS Glider Surfacing 5 | milestone | 20min | 2003-08-02 20:20 | 2003-08-02 20:40 | 169FS+2h |  |  |  | 98.99d | 0d |  |
| 84 | 7.1.15 | AS Glider Surfacing 6 | milestone | 20min | 2003-08-02 22:55 | 2003-08-02 23:15 | 170FS+2h |  |  |  | 98.99d | 0d |  |
| 85 | 7.1.16 | AS Glider Surfacing 7 | milestone | 20min | 2003-08-03 01:30 | 2003-08-03 01:50 | 171FS+2h |  |  |  | 98.99d | 0d |  |
| 86 | 7.1.17 | AS Glider Surfacing 8 | milestone | 20min | 2003-08-03 04:05 | 2003-08-03 04:25 | 172FS+2h |  |  |  | 98.99d | 0d |  |
| 87 | 7.1.18 | AS Glider Surfacing 9 | milestone | 20min | 2003-08-03 06:40 | 2003-08-03 07:00 | 173FS+2h |  |  |  | 98.99d | 0d |  |
| 88 | 7.1.19 | AS Glider Surfacing 10 | milestone | 20min | 2003-08-03 09:15 | 2003-08-03 09:35 | 174FS+2h |  |  |  | 98.99d | 0d |  |
| 89 | 7.1.20 | AS Glider Surfacing 11 | milestone | 20min | 2003-08-03 11:50 | 2003-08-03 12:10 | 175FS+2h |  |  |  | 98.99d | 0d |  |
| 90 | 7.1.21 | AS Glider Surfacing 12 | milestone | 20min | 2003-08-03 14:25 | 2003-08-03 14:45 | 176FS+2h |  |  |  | 98.99d | 0d |  |
| 91 | 7.1.22 | AS Glider Surfacing 13 | milestone | 20min | 2003-08-03 17:00 | 2003-08-03 17:20 | 177FS+2h |  |  |  | 98.99d | 0d |  |
| 92 | 7.1.23 | AS Glider Surfacing 14 | milestone | 20min | 2003-08-03 19:35 | 2003-08-03 19:55 | 178FS+2h |  |  |  | 98.99d | 0d |  |
| 93 | 7.1.24 | AS Glider Surfacing 15 | milestone | 20min | 2003-08-03 22:10 | 2003-08-03 22:30 | 179FS+2h |  |  |  | 98.99d | 0d |  |
| 94 | 7.1.25 | AS Glider Surfacing 16 | milestone | 20min | 2003-08-04 00:45 | 2003-08-04 01:05 | 180FS+2h |  |  |  | 98.99d | 0d |  |
| 95 | 7.1.26 | AS Glider Surfacing 16 | milestone | 20min | 2003-08-04 03:20 | 2003-08-04 03:40 | 181FS+2h |  |  |  | 98.99d | 0d |  |
| 96 | 7.1.27 | AS Glider Surfacing 16 | milestone | 20min | 2003-08-04 05:55 | 2003-08-04 06:15 | 182FS+2h |  |  |  | 98.99d | 0d |  |
| 97 | 7.1.28 | AS Glider Surfacing 16 | milestone | 20min | 2003-08-04 08:30 | 2003-08-04 08:50 | 183FS+2h |  |  |  | 98.99d | 0d |  |
| 98 | 7.1.29 | AS Glider Surfacing 16 | milestone | 20min | 2003-08-04 11:05 | 2003-08-04 11:25 | 184FS+2h |  |  |  | 98.99d | 0d |  |
| 99 | 7.1.30 | AS Glider Surfacing 16 | milestone | 20min | 2003-08-04 13:40 | 2003-08-04 14:00 | 185FS+2h |  |  |  | 98.99d | 0d |  |
| 100 | 7.1.31 | AS Glider Surfacing 16 | milestone | 20min | 2003-08-04 16:15 | 2003-08-04 16:35 | 186FS+2h |  |  |  | 98.99d | 0d |  |
| 101 | 7.1.32 | AS Glider Surfacing 16 | milestone | 20min | 2003-08-04 18:50 | 2003-08-04 19:10 | 187FS+2h |  |  |  | 98.99d | 0d |  |
| 102 | 7.1.33 | AS Glider Surfacing 16 | milestone | 20min | 2003-08-04 21:25 | 2003-08-04 21:45 | 188FS+2h |  |  |  | 98.99d | 0d |  |
| 103 | 7.1.34 | AS Glider Surfacing 16 | milestone | 20min | 2003-08-05 00:00 | 2003-08-05 00:20 | 189FS+2h |  |  |  | 98.99d | 0d |  |
| 104 | 7.1.35 | AS Glider Surfacing 16 | milestone | 20min | 2003-08-05 02:35 | 2003-08-05 02:55 | 190FS+2h |  |  |  | 98.99d | 0d |  |
| 105 | 7.1.36 | AS Glider Surfacing 16 | milestone | 20min | 2003-08-05 05:10 | 2003-08-05 05:30 | 191FS+2h |  |  |  | 98.99d | 0d |  |
| 106 | 7.1.37 | AS Glider Surfacing 16 | milestone | 20min | 2003-08-05 07:45 | 2003-08-05 08:05 | 192FS+2h |  |  |  | 98.99d | 0d |  |
| 107 | 7.1.38 | AS Glider Surfacing 16 | milestone | 20min | 2003-08-05 10:20 | 2003-08-05 10:40 | 193FS+2h |  |  |  | 98.99d | 0d |  |
| 108 | 7.1.39 | AS Glider Surfacing 16 | milestone | 20min | 2003-08-05 12:55 | 2003-08-05 13:15 | 194FS+2h |  |  |  | 98.99d | 0d |  |
| 109 | 7.1.40 | AS Glider Surfacing 16 | milestone | 20min | 2003-08-05 15:30 | 2003-08-05 15:50 | 195FS+2h |  |  |  | 98.99d | 0d |  |

Notes:
- 56: RTOC Deliberations

| ID | WBS | Task | Duration | Start | Finish | Predecessors | Baseline start | Baseline finish | Baseline duration | Total slack | Free slack |
| --- | --- | --- | --- | --- | --- | --- | --- | --- | --- | --- | --- |
| 110 | 7.2 | **AS Observation Data Avail** | 8.73d | 2003-08-02 18:05 | 2003-08-05 15:55 |  | 2003-08-02 08:20 | 2003-08-02 08:25 | 0.01d | 98.99d |  |
| 111 | 7.2.1 | AS Observation Data QC4 | 5min | 2003-08-02 18:05 | 2003-08-02 18:10 | 82 |  |  |  | 98.99d | 0d |
| 112 | 7.2.2 | AS Observation Data QC5 | 5min | 2003-08-02 20:40 | 2003-08-02 20:45 | 83 |  |  |  | 98.99d | 0d |
| 113 | 7.2.3 | AS Observation Data QC6 | 5min | 2003-08-02 23:15 | 2003-08-02 23:20 | 84 |  |  |  | 98.99d | 0d |
| 114 | 7.2.4 | AS Observation Data QC7 | 5min | 2003-08-03 01:50 | 2003-08-03 01:55 | 85 |  |  |  | 98.99d | 0d |
| 115 | 7.2.5 | AS Observation Data QC8 | 5min | 2003-08-03 04:25 | 2003-08-03 04:30 | 86 |  |  |  | 98.99d | 0d |
| 116 | 7.2.6 | AS Observation Data QC9 | 5min | 2003-08-03 07:00 | 2003-08-03 07:05 | 87 |  |  |  | 98.99d | 0d |
| 117 | 7.2.7 | AS Observation Data QC10 | 5min | 2003-08-03 09:35 | 2003-08-03 09:40 | 88 |  |  |  | 98.99d | 0d |
| 118 | 7.2.8 | AS Observation Data QC11 | 5min | 2003-08-03 12:10 | 2003-08-03 12:15 | 89 |  |  |  | 98.99d | 0d |
| 119 | 7.2.9 | AS Observation Data QC12 | 5min | 2003-08-03 14:45 | 2003-08-03 14:50 | 90 |  |  |  | 98.99d | 0d |
| 120 | 7.2.10 | AS Observation Data QC13 | 5min | 2003-08-03 17:20 | 2003-08-03 17:25 | 91 |  |  |  | 98.99d | 0d |
| 121 | 7.2.11 | AS Observation Data QC14 | 5min | 2003-08-03 19:55 | 2003-08-03 20:00 | 92 |  |  |  | 98.99d | 0d |
| 122 | 7.2.12 | AS Observation Data QC15 | 5min | 2003-08-03 22:30 | 2003-08-03 22:35 | 93 |  |  |  | 98.99d | 0d |
| 123 | 7.2.13 | AS Observation Data QC16 | 5min | 2003-08-04 01:05 | 2003-08-04 01:10 | 94 |  |  |  | 98.99d | 0d |
| 124 | 7.2.14 | AS Observation Data QC16 | 5min | 2003-08-04 03:40 | 2003-08-04 03:45 | 95 |  |  |  | 98.99d | 0d |
| 125 | 7.2.15 | AS Observation Data QC16 | 5min | 2003-08-04 06:15 | 2003-08-04 06:20 | 96 |  |  |  | 98.99d | 0d |
| 126 | 7.2.16 | AS Observation Data QC16 | 5min | 2003-08-04 08:50 | 2003-08-04 08:55 | 97 |  |  |  | 98.99d | 0d |
| 127 | 7.2.17 | AS Observation Data QC16 | 5min | 2003-08-04 11:25 | 2003-08-04 11:30 | 98 |  |  |  | 98.99d | 0d |
| 128 | 7.2.18 | AS Observation Data QC16 | 5min | 2003-08-04 14:00 | 2003-08-04 14:05 | 99 |  |  |  | 98.99d | 0d |
| 129 | 7.2.19 | AS Observation Data QC16 | 5min | 2003-08-04 16:35 | 2003-08-04 16:40 | 100 |  |  |  | 98.99d | 0d |
| 130 | 7.2.20 | AS Observation Data QC16 | 5min | 2003-08-04 19:10 | 2003-08-04 19:15 | 101 |  |  |  | 98.99d | 0d |
| 131 | 7.2.21 | AS Observation Data QC16 | 5min | 2003-08-04 21:45 | 2003-08-04 21:50 | 102 |  |  |  | 98.99d | 0d |
| 132 | 7.2.22 | AS Observation Data QC16 | 5min | 2003-08-05 00:20 | 2003-08-05 00:25 | 103 |  |  |  | 98.99d | 0d |
| 133 | 7.2.23 | AS Observation Data QC16 | 5min | 2003-08-05 02:55 | 2003-08-05 03:00 | 104 |  |  |  | 98.99d | 0d |
| 134 | 7.2.24 | AS Observation Data QC16 | 5min | 2003-08-05 05:30 | 2003-08-05 05:35 | 105 |  |  |  | 98.99d | 0d |
| 135 | 7.2.25 | AS Observation Data QC16 | 5min | 2003-08-05 08:05 | 2003-08-05 08:10 | 106 |  |  |  | 98.99d | 0d |
| 136 | 7.2.26 | AS Observation Data QC16 | 5min | 2003-08-05 10:40 | 2003-08-05 10:45 | 107 |  |  |  | 98.99d | 0d |
| 137 | 7.2.27 | AS Observation Data QC16 | 5min | 2003-08-05 13:15 | 2003-08-05 13:20 | 108 |  |  |  | 98.99d | 0d |
| 138 | 7.2.28 | AS Observation Data QC16 | 5min | 2003-08-05 15:50 | 2003-08-05 15:55 | 109 |  |  |  | 98.99d | 0d |

| ID | WBS | Task | Duration | Start | Finish | Predecessors | Baseline start | Baseline finish | Baseline duration | Total slack | Free slack |
| --- | --- | --- | --- | --- | --- | --- | --- | --- | --- | --- | --- |
| 139 | 7.3 | **AS Feedback Control** | 8.74d | 2003-08-02 18:10 | 2003-08-05 16:05 |  | 2003-07-14 08:00 | 2003-08-02 21:33 | 58.69d | 98.99d |  |
| 140 | 7.3.1 | AS Feedback Control 2 | 10min | 2003-08-02 18:10 | 2003-08-02 18:20 | 111 |  |  |  | 98.99d | 0d |
| 141 | 7.3.2 | AS Feedback Control 2 | 10min | 2003-08-02 20:45 | 2003-08-02 20:55 | 112 |  |  |  | 98.99d | 0d |
| 142 | 7.3.3 | AS Feedback Control 2 | 10min | 2003-08-02 23:20 | 2003-08-02 23:30 | 113 |  |  |  | 98.99d | 0d |
| 143 | 7.3.4 | AS Feedback Control 2 | 10min | 2003-08-03 01:55 | 2003-08-03 02:05 | 114 |  |  |  | 98.99d | 0d |
| 144 | 7.3.5 | AS Feedback Control 2 | 10min | 2003-08-03 04:30 | 2003-08-03 04:40 | 115 |  |  |  | 98.99d | 0d |
| 145 | 7.3.6 | AS Feedback Control 2 | 10min | 2003-08-03 07:05 | 2003-08-03 07:15 | 116 |  |  |  | 98.99d | 0d |
| 146 | 7.3.7 | AS Feedback Control 2 | 10min | 2003-08-03 09:40 | 2003-08-03 09:50 | 117 |  |  |  | 98.99d | 0d |
| 147 | 7.3.8 | AS Feedback Control 2 | 10min | 2003-08-03 12:15 | 2003-08-03 12:25 | 118 |  |  |  | 98.99d | 0d |
| 148 | 7.3.9 | AS Feedback Control 2 | 10min | 2003-08-03 14:50 | 2003-08-03 15:00 | 119 |  |  |  | 98.99d | 0d |
| 149 | 7.3.10 | AS Feedback Control 2 | 10min | 2003-08-03 17:25 | 2003-08-03 17:35 | 120 |  |  |  | 98.99d | 0d |
| 150 | 7.3.11 | AS Feedback Control 2 | 10min | 2003-08-03 20:00 | 2003-08-03 20:10 | 121 |  |  |  | 98.99d | 0d |
| 151 | 7.3.12 | AS Feedback Control 2 | 10min | 2003-08-03 22:35 | 2003-08-03 22:45 | 122 |  |  |  | 98.99d | 0d |
| 152 | 7.3.13 | AS Feedback Control 2 | 10min | 2003-08-04 01:10 | 2003-08-04 01:20 | 123 |  |  |  | 98.99d | 0d |
| 153 | 7.3.14 | AS Feedback Control 2 | 10min | 2003-08-04 03:45 | 2003-08-04 03:55 | 124 |  |  |  | 98.99d | 0d |
| 154 | 7.3.15 | AS Feedback Control 2 | 10min | 2003-08-04 06:20 | 2003-08-04 06:30 | 125 |  |  |  | 98.99d | 0d |
| 155 | 7.3.16 | AS Feedback Control 2 | 10min | 2003-08-04 08:55 | 2003-08-04 09:05 | 126 |  |  |  | 98.99d | 0d |
| 156 | 7.3.17 | AS Feedback Control 2 | 10min | 2003-08-04 11:30 | 2003-08-04 11:40 | 127 |  |  |  | 98.99d | 0d |
| 157 | 7.3.18 | AS Feedback Control 2 | 10min | 2003-08-04 14:05 | 2003-08-04 14:15 | 128 |  |  |  | 98.99d | 0d |
| 158 | 7.3.19 | AS Feedback Control 2 | 10min | 2003-08-04 16:40 | 2003-08-04 16:50 | 129 |  |  |  | 98.99d | 0d |
| 159 | 7.3.20 | AS Feedback Control 2 | 10min | 2003-08-04 19:15 | 2003-08-04 19:25 | 130 |  |  |  | 98.99d | 0d |
| 160 | 7.3.21 | AS Feedback Control 2 | 10min | 2003-08-04 21:50 | 2003-08-04 22:00 | 131 |  |  |  | 98.99d | 0d |
| 161 | 7.3.22 | AS Feedback Control 2 | 10min | 2003-08-05 00:25 | 2003-08-05 00:35 | 132 |  |  |  | 98.99d | 0d |
| 162 | 7.3.23 | AS Feedback Control 2 | 10min | 2003-08-05 03:00 | 2003-08-05 03:10 | 133 |  |  |  | 98.99d | 0d |
| 163 | 7.3.24 | AS Feedback Control 2 | 10min | 2003-08-05 05:35 | 2003-08-05 05:45 | 134 |  |  |  | 98.99d | 0d |
| 164 | 7.3.25 | AS Feedback Control 2 | 10min | 2003-08-05 08:10 | 2003-08-05 08:20 | 135 |  |  |  | 98.99d | 0d |
| 165 | 7.3.26 | AS Feedback Control 2 | 10min | 2003-08-05 10:45 | 2003-08-05 10:55 | 136 |  |  |  | 98.99d | 0d |
| 166 | 7.3.27 | AS Feedback Control 2 | 10min | 2003-08-05 13:20 | 2003-08-05 13:30 | 137 |  |  |  | 98.99d | 0d |
| 167 | 7.3.28 | AS Feedback Control 2 | 10min | 2003-08-05 15:55 | 2003-08-05 16:05 | 138 |  |  |  | 98.99d | 0d |

| ID | WBS | Task | Type | Duration | Start | Finish | Predecessors | Baseline start | Baseline finish | Baseline duration | Total slack | Free slack |
| --- | --- | --- | --- | --- | --- | --- | --- | --- | --- | --- | --- | --- |
| 168 | 7.4 | **AS Glider Dive** |  | 8.72d | 2003-08-02 18:20 | 2003-08-05 16:05 |  | 2003-07-14 08:10 | 2003-08-02 08:35 | 57.05d | 98.99d |  |
| 169 | 7.4.1 | AS Glider Dive 2 | milestone | 0h | 2003-08-02 18:20 | 2003-08-02 18:20 | 140 |  |  |  | 98.99d | 0d |
| 170 | 7.4.2 | AS Glider Dive 2 | milestone | 0h | 2003-08-02 20:55 | 2003-08-02 20:55 | 141 |  |  |  | 98.99d | 0d |
| 171 | 7.4.3 | AS Glider Dive 2 | milestone | 0h | 2003-08-02 23:30 | 2003-08-02 23:30 | 142 |  |  |  | 98.99d | 0d |
| 172 | 7.4.4 | AS Glider Dive 2 | milestone | 0h | 2003-08-03 02:05 | 2003-08-03 02:05 | 143 |  |  |  | 98.99d | 0d |
| 173 | 7.4.5 | AS Glider Dive 2 | milestone | 0h | 2003-08-03 04:40 | 2003-08-03 04:40 | 144 |  |  |  | 98.99d | 0d |
| 174 | 7.4.6 | AS Glider Dive 2 | milestone | 0h | 2003-08-03 07:15 | 2003-08-03 07:15 | 145 |  |  |  | 98.99d | 0d |
| 175 | 7.4.7 | AS Glider Dive 2 | milestone | 0h | 2003-08-03 09:50 | 2003-08-03 09:50 | 146 |  |  |  | 98.99d | 0d |
| 176 | 7.4.8 | AS Glider Dive 2 | milestone | 0h | 2003-08-03 12:25 | 2003-08-03 12:25 | 147 |  |  |  | 98.99d | 0d |
| 177 | 7.4.9 | AS Glider Dive 2 | milestone | 0h | 2003-08-03 15:00 | 2003-08-03 15:00 | 148 |  |  |  | 98.99d | 0d |
| 178 | 7.4.10 | AS Glider Dive 2 | milestone | 0h | 2003-08-03 17:35 | 2003-08-03 17:35 | 149 |  |  |  | 98.99d | 0d |
| 179 | 7.4.11 | AS Glider Dive 2 | milestone | 0h | 2003-08-03 20:10 | 2003-08-03 20:10 | 150 |  |  |  | 98.99d | 0d |
| 180 | 7.4.12 | AS Glider Dive 2 | milestone | 0h | 2003-08-03 22:45 | 2003-08-03 22:45 | 151 |  |  |  | 98.99d | 0d |
| 181 | 7.4.13 | AS Glider Dive 2 | milestone | 0h | 2003-08-04 01:20 | 2003-08-04 01:20 | 152 |  |  |  | 98.99d | 0d |
| 182 | 7.4.14 | AS Glider Dive 2 | milestone | 0h | 2003-08-04 03:55 | 2003-08-04 03:55 | 153 |  |  |  | 98.99d | 0d |
| 183 | 7.4.15 | AS Glider Dive 2 | milestone | 0h | 2003-08-04 06:30 | 2003-08-04 06:30 | 154 |  |  |  | 98.99d | 0d |
| 184 | 7.4.16 | AS Glider Dive 2 | milestone | 0h | 2003-08-04 09:05 | 2003-08-04 09:05 | 155 |  |  |  | 98.99d | 0d |
| 185 | 7.4.17 | AS Glider Dive 2 | milestone | 0h | 2003-08-04 11:40 | 2003-08-04 11:40 | 156 |  |  |  | 98.99d | 0d |
| 186 | 7.4.18 | AS Glider Dive 2 | milestone | 0h | 2003-08-04 14:15 | 2003-08-04 14:15 | 157 |  |  |  | 98.99d | 0d |
| 187 | 7.4.19 | AS Glider Dive 2 | milestone | 0h | 2003-08-04 16:50 | 2003-08-04 16:50 | 158 |  |  |  | 98.99d | 0d |
| 188 | 7.4.20 | AS Glider Dive 2 | milestone | 0h | 2003-08-04 19:25 | 2003-08-04 19:25 | 159 |  |  |  | 98.99d | 0d |
| 189 | 7.4.21 | AS Glider Dive 2 | milestone | 0h | 2003-08-04 22:00 | 2003-08-04 22:00 | 160 |  |  |  | 98.99d | 0d |
| 190 | 7.4.22 | AS Glider Dive 2 | milestone | 0h | 2003-08-05 00:35 | 2003-08-05 00:35 | 161 |  |  |  | 98.99d | 0d |
| 191 | 7.4.23 | AS Glider Dive 2 | milestone | 0h | 2003-08-05 03:10 | 2003-08-05 03:10 | 162 |  |  |  | 98.99d | 0d |
| 192 | 7.4.24 | AS Glider Dive 2 | milestone | 0h | 2003-08-05 05:45 | 2003-08-05 05:45 | 163 |  |  |  | 98.99d | 0d |
| 193 | 7.4.25 | AS Glider Dive 2 | milestone | 0h | 2003-08-05 08:20 | 2003-08-05 08:20 | 164 |  |  |  | 98.99d | 0d |
| 194 | 7.4.26 | AS Glider Dive 2 | milestone | 0h | 2003-08-05 10:55 | 2003-08-05 10:55 | 165 |  |  |  | 98.99d | 0d |
| 195 | 7.4.27 | AS Glider Dive 2 | milestone | 0h | 2003-08-05 13:30 | 2003-08-05 13:30 | 166 |  |  |  | 98.99d | 0d |
| 196 | 7.4.28 | AS Glider Dive 2 | milestone | 0h | 2003-08-05 16:05 | 2003-08-05 16:05 | 167 |  |  |  | 98.99d |  |

| ID | WBS | Task | Duration | Start | Finish | Predecessors | Total slack | Free slack | Constraint |
| --- | --- | --- | --- | --- | --- | --- | --- | --- | --- |
| 197 | 8 | **Slocum Pattern Glider Ops** | 9.5d | 2003-08-02 10:00 | 2003-08-05 14:00 |  | 99.25d |  |  |
| 198 | 8.1 | Glider Surface 1 | 10min | 2003-08-02 10:00 | 2003-08-02 10:10 |  | 99.25d | 0d | start no earlier than 2003-08-02 10:00 |
| 199 | 8.2 | Glider Surface 1 | 10min | 2003-08-02 12:10 | 2003-08-02 12:20 | 198FS+2h | 99.25d | 0d |  |
| 200 | 8.3 | Glider Surface 1 | 10min | 2003-08-02 14:20 | 2003-08-02 14:30 | 199FS+2h | 99.25d | 0d |  |
| 201 | 8.4 | Glider Surface 1 | 10min | 2003-08-02 16:30 | 2003-08-02 16:40 | 200FS+2h | 99.25d | 0d |  |
| 202 | 8.5 | Glider Surface 1 | 10min | 2003-08-02 18:40 | 2003-08-02 18:50 | 201FS+2h | 99.25d | 0d |  |
| 203 | 8.6 | Glider Surface 1 | 10min | 2003-08-02 20:50 | 2003-08-02 21:00 | 202FS+2h | 99.25d | 0d |  |
| 204 | 8.7 | Glider Surface 1 | 10min | 2003-08-02 23:00 | 2003-08-02 23:10 | 203FS+2h | 99.25d | 0d |  |
| 205 | 8.8 | Glider Surface 1 | 10min | 2003-08-03 01:10 | 2003-08-03 01:20 | 204FS+2h | 99.25d | 0d |  |
| 206 | 8.9 | Glider Surface 1 | 10min | 2003-08-03 03:20 | 2003-08-03 03:30 | 205FS+2h | 99.25d | 0d |  |
| 207 | 8.10 | Glider Surface 1 | 10min | 2003-08-03 05:30 | 2003-08-03 05:40 | 206FS+2h | 99.25d | 0d |  |
| 208 | 8.11 | Glider Surface 1 | 10min | 2003-08-03 07:40 | 2003-08-03 07:50 | 207FS+2h | 99.25d | 0d |  |
| 209 | 8.12 | Glider Surface 1 | 10min | 2003-08-03 09:50 | 2003-08-03 10:00 | 208FS+2h | 99.25d | 0d |  |
| 210 | 8.13 | Glider Surface 1 | 10min | 2003-08-03 12:00 | 2003-08-03 12:10 | 209FS+2h | 99.25d | 0d |  |
| 211 | 8.14 | Glider Surface 1 | 10min | 2003-08-03 14:10 | 2003-08-03 14:20 | 210FS+2h | 99.25d | 0d |  |
| 212 | 8.15 | Glider Surface 1 | 10min | 2003-08-03 16:20 | 2003-08-03 16:30 | 211FS+2h | 99.25d | 0d |  |
| 213 | 8.16 | Glider Surface 1 | 10min | 2003-08-03 18:30 | 2003-08-03 18:40 | 212FS+2h | 99.25d | 0d |  |
| 214 | 8.17 | Glider Surface 1 | 10min | 2003-08-03 20:40 | 2003-08-03 20:50 | 213FS+2h | 99.25d | 0d |  |
| 215 | 8.18 | Glider Surface 1 | 10min | 2003-08-03 22:50 | 2003-08-03 23:00 | 214FS+2h | 99.25d | 0d |  |
| 216 | 8.19 | Glider Surface 1 | 10min | 2003-08-04 01:00 | 2003-08-04 01:10 | 215FS+2h | 99.25d | 0d |  |
| 217 | 8.20 | Glider Surface 1 | 10min | 2003-08-04 03:10 | 2003-08-04 03:20 | 216FS+2h | 99.25d | 0d |  |
| 218 | 8.21 | Glider Surface 1 | 10min | 2003-08-04 05:20 | 2003-08-04 05:30 | 217FS+2h | 99.25d | 0d |  |
| 219 | 8.22 | Glider Surface 1 | 10min | 2003-08-04 07:30 | 2003-08-04 07:40 | 218FS+2h | 99.25d | 0d |  |
| 220 | 8.23 | Glider Surface 1 | 10min | 2003-08-04 09:40 | 2003-08-04 09:50 | 219FS+2h | 99.25d | 0d |  |
| 221 | 8.24 | Glider Surface 1 | 10min | 2003-08-04 11:50 | 2003-08-04 12:00 | 220FS+2h | 99.25d | 0d |  |
| 222 | 8.25 | Glider Surface 1 | 10min | 2003-08-04 14:00 | 2003-08-04 14:10 | 221FS+2h | 99.25d | 0d |  |
| 223 | 8.26 | Glider Surface 1 | 10min | 2003-08-04 16:10 | 2003-08-04 16:20 | 222FS+2h | 99.25d | 0d |  |
| 224 | 8.27 | Glider Surface 1 | 10min | 2003-08-04 18:20 | 2003-08-04 18:30 | 223FS+2h | 99.25d | 0d |  |
| 225 | 8.28 | Glider Surface 1 | 10min | 2003-08-04 20:30 | 2003-08-04 20:40 | 224FS+2h | 99.25d | 0d |  |
| 226 | 8.29 | Glider Surface 1 | 10min | 2003-08-04 22:40 | 2003-08-04 22:50 | 225FS+2h | 99.25d | 0d |  |
| 227 | 8.30 | Glider Surface 1 | 10min | 2003-08-05 00:50 | 2003-08-05 01:00 | 226FS+2h | 99.25d | 0d |  |
| 228 | 8.31 | Glider Surface 1 | 10min | 2003-08-05 03:00 | 2003-08-05 03:10 | 227FS+2h | 99.25d | 0d |  |
| 229 | 8.32 | Glider Surface 1 | 10min | 2003-08-05 05:10 | 2003-08-05 05:20 | 228FS+2h | 99.25d | 0d |  |
| 230 | 8.33 | Glider Surface 1 | 10min | 2003-08-05 07:20 | 2003-08-05 07:30 | 229FS+2h | 99.25d | 0d |  |
| 231 | 8.34 | Glider Surface 1 | 10min | 2003-08-05 09:30 | 2003-08-05 09:40 | 230FS+2h | 99.25d | 0d |  |
| 232 | 8.35 | Glider Surface 1 | 10min | 2003-08-05 11:40 | 2003-08-05 11:50 | 231FS+2h | 99.25d | 0d |  |
| 233 | 8.36 | Glider Surface 1 | 10min | 2003-08-05 13:50 | 2003-08-05 14:00 | 232FS+2h | 99.25d |  |  |

| ID | WBS | Task | Duration | Start | Finish | Predecessors | Total slack | Free slack | Constraint |
| --- | --- | --- | --- | --- | --- | --- | --- | --- | --- |
| 234 | 9 | **Spray Pattern Glider Ops** | 9.5d | 2003-08-02 10:00 | 2003-08-05 14:00 |  | 99.25d |  |  |
| 235 | 9.1 | Glider Surface 1 | 10min | 2003-08-02 10:00 | 2003-08-02 10:10 |  | 99.25d | 0d | start no earlier than 2003-08-02 10:00 |
| 236 | 9.2 | Glider Surface 1 | 10min | 2003-08-02 12:10 | 2003-08-02 12:20 | 235FS+2h | 99.25d | 0d |  |
| 237 | 9.3 | Glider Surface 1 | 10min | 2003-08-02 14:20 | 2003-08-02 14:30 | 236FS+2h | 99.25d | 0d |  |
| 238 | 9.4 | Glider Surface 1 | 10min | 2003-08-02 16:30 | 2003-08-02 16:40 | 237FS+2h | 99.25d | 0d |  |
| 239 | 9.5 | Glider Surface 1 | 10min | 2003-08-02 18:40 | 2003-08-02 18:50 | 238FS+2h | 99.25d | 0d |  |
| 240 | 9.6 | Glider Surface 1 | 10min | 2003-08-02 20:50 | 2003-08-02 21:00 | 239FS+2h | 99.25d | 0d |  |
| 241 | 9.7 | Glider Surface 1 | 10min | 2003-08-02 23:00 | 2003-08-02 23:10 | 240FS+2h | 99.25d | 0d |  |
| 242 | 9.8 | Glider Surface 1 | 10min | 2003-08-03 01:10 | 2003-08-03 01:20 | 241FS+2h | 99.25d | 0d |  |
| 243 | 9.9 | Glider Surface 1 | 10min | 2003-08-03 03:20 | 2003-08-03 03:30 | 242FS+2h | 99.25d | 0d |  |
| 244 | 9.10 | Glider Surface 1 | 10min | 2003-08-03 05:30 | 2003-08-03 05:40 | 243FS+2h | 99.25d | 0d |  |
| 245 | 9.11 | Glider Surface 1 | 10min | 2003-08-03 07:40 | 2003-08-03 07:50 | 244FS+2h | 99.25d | 0d |  |
| 246 | 9.12 | Glider Surface 1 | 10min | 2003-08-03 09:50 | 2003-08-03 10:00 | 245FS+2h | 99.25d | 0d |  |
| 247 | 9.13 | Glider Surface 1 | 10min | 2003-08-03 12:00 | 2003-08-03 12:10 | 246FS+2h | 99.25d | 0d |  |
| 248 | 9.14 | Glider Surface 1 | 10min | 2003-08-03 14:10 | 2003-08-03 14:20 | 247FS+2h | 99.25d | 0d |  |
| 249 | 9.15 | Glider Surface 1 | 10min | 2003-08-03 16:20 | 2003-08-03 16:30 | 248FS+2h | 99.25d | 0d |  |
| 250 | 9.16 | Glider Surface 1 | 10min | 2003-08-03 18:30 | 2003-08-03 18:40 | 249FS+2h | 99.25d | 0d |  |
| 251 | 9.17 | Glider Surface 1 | 10min | 2003-08-03 20:40 | 2003-08-03 20:50 | 250FS+2h | 99.25d | 0d |  |
| 252 | 9.18 | Glider Surface 1 | 10min | 2003-08-03 22:50 | 2003-08-03 23:00 | 251FS+2h | 99.25d | 0d |  |
| 253 | 9.19 | Glider Surface 1 | 10min | 2003-08-04 01:00 | 2003-08-04 01:10 | 252FS+2h | 99.25d | 0d |  |
| 254 | 9.20 | Glider Surface 1 | 10min | 2003-08-04 03:10 | 2003-08-04 03:20 | 253FS+2h | 99.25d | 0d |  |
| 255 | 9.21 | Glider Surface 1 | 10min | 2003-08-04 05:20 | 2003-08-04 05:30 | 254FS+2h | 99.25d | 0d |  |
| 256 | 9.22 | Glider Surface 1 | 10min | 2003-08-04 07:30 | 2003-08-04 07:40 | 255FS+2h | 99.25d | 0d |  |
| 257 | 9.23 | Glider Surface 1 | 10min | 2003-08-04 09:40 | 2003-08-04 09:50 | 256FS+2h | 99.25d | 0d |  |
| 258 | 9.24 | Glider Surface 1 | 10min | 2003-08-04 11:50 | 2003-08-04 12:00 | 257FS+2h | 99.25d | 0d |  |
| 259 | 9.25 | Glider Surface 1 | 10min | 2003-08-04 14:00 | 2003-08-04 14:10 | 258FS+2h | 99.25d | 0d |  |
| 260 | 9.26 | Glider Surface 1 | 10min | 2003-08-04 16:10 | 2003-08-04 16:20 | 259FS+2h | 99.25d | 0d |  |
| 261 | 9.27 | Glider Surface 1 | 10min | 2003-08-04 18:20 | 2003-08-04 18:30 | 260FS+2h | 99.25d | 0d |  |
| 262 | 9.28 | Glider Surface 1 | 10min | 2003-08-04 20:30 | 2003-08-04 20:40 | 261FS+2h | 99.25d | 0d |  |
| 263 | 9.29 | Glider Surface 1 | 10min | 2003-08-04 22:40 | 2003-08-04 22:50 | 262FS+2h | 99.25d | 0d |  |
| 264 | 9.30 | Glider Surface 1 | 10min | 2003-08-05 00:50 | 2003-08-05 01:00 | 263FS+2h | 99.25d | 0d |  |
| 265 | 9.31 | Glider Surface 1 | 10min | 2003-08-05 03:00 | 2003-08-05 03:10 | 264FS+2h | 99.25d | 0d |  |
| 266 | 9.32 | Glider Surface 1 | 10min | 2003-08-05 05:10 | 2003-08-05 05:20 | 265FS+2h | 99.25d | 0d |  |
| 267 | 9.33 | Glider Surface 1 | 10min | 2003-08-05 07:20 | 2003-08-05 07:30 | 266FS+2h | 99.25d | 0d |  |
| 268 | 9.34 | Glider Surface 1 | 10min | 2003-08-05 09:30 | 2003-08-05 09:40 | 267FS+2h | 99.25d | 0d |  |
| 269 | 9.35 | Glider Surface 1 | 10min | 2003-08-05 11:40 | 2003-08-05 11:50 | 268FS+2h | 99.25d | 0d |  |
| 270 | 9.36 | Glider Surface 1 | 10min | 2003-08-05 13:50 | 2003-08-05 14:00 | 269FS+2h | 99.25d |  |  |

| ID | WBS | Task | Type | Duration | Start | Finish | Predecessors | Total slack | Free slack | Constraint |
| --- | --- | --- | --- | --- | --- | --- | --- | --- | --- | --- |
| 271 | 10 | **Twin Otter Flight Ops** |  | 13d | 2003-08-02 12:00 | 2003-08-06 20:00 |  | 95.5d |  |  |
| 272 | 10.1 | **Twin Otter Flights** |  | 12.5d | 2003-08-02 12:00 | 2003-08-06 16:00 |  | 95.5d |  |  |
| 273 | 10.1.1 | Twin Otter Flight 1 |  | 4h | 2003-08-02 12:00 | 2003-08-02 16:00 |  | 107.5d | 0d | start no earlier than 2003-08-02 12:00 |
| 274 | 10.1.2 | Twin Otter Flight 2 |  | 4h | 2003-08-03 12:00 | 2003-08-03 16:00 |  | 104.5d | 0d | start no earlier than 2003-08-03 12:00 |
| 275 | 10.1.3 | Twin Otter Flight 3 |  | 4h | 2003-08-04 12:00 | 2003-08-04 16:00 |  | 101.5d | 0d | start no earlier than 2003-08-04 12:00 |
| 276 | 10.1.4 | Twin Oter Flight 4 |  | 4h | 2003-08-06 12:00 | 2003-08-06 16:00 |  | 95.5d | 0d | start no earlier than 2003-08-06 12:00 |
| 277 | 10.2 | **Twin Otter Data Reduction** |  | 12.5d | 2003-08-02 16:00 | 2003-08-06 20:00 |  | 95.5d |  |  |
| 278 | 10.2.1 | Twin otter DR 2 |  | 4h | 2003-08-02 16:00 | 2003-08-02 20:00 | 273 | 107.5d | 0d |  |
| 279 | 10.2.2 | Twin otter DR 2 |  | 4h | 2003-08-03 16:00 | 2003-08-03 20:00 | 274 | 104.5d | 0d |  |
| 280 | 10.2.3 | Twin Otter DR 3 |  | 4h | 2003-08-04 16:00 | 2003-08-04 20:00 | 275 | 101.5d | 0d |  |
| 281 | 10.2.4 | Twin Otter DR 4 |  | 4h | 2003-08-06 16:00 | 2003-08-06 20:00 | 276 | 95.5d | 0d |  |
| 282 | 10.3 | **Twin Otter Data to RTOC** |  | 12d | 2003-08-02 20:00 | 2003-08-06 20:00 |  | 95.5d |  |  |
| 283 | 10.3.1 | Day 1 | milestone | 0h | 2003-08-02 20:00 | 2003-08-02 20:00 | 278 | 107.5d |  |  |
| 284 | 10.3.2 | Day 1 | milestone | 0h | 2003-08-03 20:00 | 2003-08-03 20:00 | 279 | 104.5d |  |  |
| 285 | 10.3.3 | Day 2 | milestone | 0h | 2003-08-04 20:00 | 2003-08-04 20:00 | 280 | 101.5d |  |  |
| 286 | 10.3.4 | Day 3 | milestone | 0h | 2003-08-06 20:00 | 2003-08-06 20:00 | 281 | 95.5d |  |  |
| 287 | 11 | **ADCP Data** |  | 11d | 2003-08-02 16:00 | 2003-08-06 08:00 |  | 97d |  |  |
| 288 | 11.1 | ADCP Data 1 | milestone | 0h | 2003-08-02 16:00 | 2003-08-02 16:00 |  | 108d |  | start no earlier than 2003-08-02 16:00 |
| 289 | 11.2 | ADCP Data 2 | milestone | 0h | 2003-08-04 08:00 | 2003-08-04 08:00 |  | 103d |  | start no earlier than 2003-08-04 08:00 |
| 290 | 11.3 | ADCP Data 3 | milestone | 0h | 2003-08-06 08:00 | 2003-08-06 08:00 |  | 97d |  | start no earlier than 2003-08-06 08:00 |
| 291 | 12 | **M1/M2/CODAR Data Available** |  | 9.88d | 2003-08-02 08:00 | 2003-08-05 15:00 |  | 99.12d |  |  |
| 292 | 12.1 | M1 Data 1 | milestone | 0h | 2003-08-02 08:00 | 2003-08-02 08:00 |  | 109d |  |  |
| 293 | 12.2 | M1 Data 1 | milestone | 0h | 2003-08-02 09:00 | 2003-08-02 09:00 |  | 108.88d |  | start no earlier than 2003-08-02 09:00 |
| 294 | 12.3 | M1 Data 1 | milestone | 0h | 2003-08-02 10:00 | 2003-08-02 10:00 |  | 99.12d | 0d | start no earlier than 2003-08-02 10:00 |
| 295 | 12.4 | M1 Data 1 | milestone | 1h | 2003-08-02 10:00 | 2003-08-02 11:00 | 294 | 99.12d | 0d |  |
| 296 | 12.5 | M1 Data 1 | milestone | 1h | 2003-08-02 11:00 | 2003-08-02 12:00 | 295 | 99.12d | 0d |  |
| 297 | 12.6 | M1 Data 1 | milestone | 1h | 2003-08-02 12:00 | 2003-08-02 13:00 | 296 | 99.12d | 0d |  |
| 298 | 12.7 | M1 Data 1 | milestone | 1h | 2003-08-02 13:00 | 2003-08-02 14:00 | 297 | 99.12d | 0d |  |
| 299 | 12.8 | M1 Data 1 | milestone | 1h | 2003-08-02 14:00 | 2003-08-02 15:00 | 298 | 99.12d | 0d |  |
| 300 | 12.9 | M1 Data 1 | milestone | 1h | 2003-08-02 15:00 | 2003-08-02 16:00 | 299 | 99.12d | 0d |  |
| 301 | 12.10 | M1 Data 1 | milestone | 1h | 2003-08-02 16:00 | 2003-08-02 17:00 | 300 | 99.12d | 0d |  |
| 302 | 12.11 | M1 Data 1 | milestone | 1h | 2003-08-02 17:00 | 2003-08-02 18:00 | 301 | 99.12d | 0d |  |
| 303 | 12.12 | M1 Data 1 | milestone | 1h | 2003-08-02 18:00 | 2003-08-02 19:00 | 302 | 99.12d | 0d |  |
| 304 | 12.13 | M1 Data 1 | milestone | 1h | 2003-08-02 19:00 | 2003-08-02 20:00 | 303 | 99.12d | 0d |  |
| 305 | 12.14 | M1 Data 1 | milestone | 1h | 2003-08-02 20:00 | 2003-08-02 21:00 | 304 | 99.12d | 0d |  |
| 306 | 12.15 | M1 Data 1 | milestone | 1h | 2003-08-02 21:00 | 2003-08-02 22:00 | 305 | 99.12d | 0d |  |
| 307 | 12.16 | M1 Data 1 | milestone | 1h | 2003-08-02 22:00 | 2003-08-02 23:00 | 306 | 99.12d | 0d |  |
| 308 | 12.17 | M1 Data 1 | milestone | 1h | 2003-08-02 23:00 | 2003-08-03 00:00 | 307 | 99.12d | 0d |  |
| 309 | 12.18 | M1 Data 1 | milestone | 1h | 2003-08-03 00:00 | 2003-08-03 01:00 | 308 | 99.12d | 0d |  |
| 310 | 12.19 | M1 Data 1 | milestone | 1h | 2003-08-03 01:00 | 2003-08-03 02:00 | 309 | 99.12d | 0d |  |
| 311 | 12.20 | M1 Data 1 | milestone | 1h | 2003-08-03 02:00 | 2003-08-03 03:00 | 310 | 99.12d | 0d |  |
| 312 | 12.21 | M1 Data 1 | milestone | 1h | 2003-08-03 03:00 | 2003-08-03 04:00 | 311 | 99.12d | 0d |  |
| 313 | 12.22 | M1 Data 1 | milestone | 1h | 2003-08-03 04:00 | 2003-08-03 05:00 | 312 | 99.12d | 0d |  |
| 314 | 12.23 | M1 Data 1 | milestone | 1h | 2003-08-03 05:00 | 2003-08-03 06:00 | 313 | 99.12d | 0d |  |
| 315 | 12.24 | M1 Data 1 | milestone | 1h | 2003-08-03 06:00 | 2003-08-03 07:00 | 314 | 99.12d | 0d |  |
| 316 | 12.25 | M1 Data 1 | milestone | 1h | 2003-08-03 07:00 | 2003-08-03 08:00 | 315 | 99.12d | 0d |  |
| 317 | 12.26 | M1 Data 1 | milestone | 1h | 2003-08-03 08:00 | 2003-08-03 09:00 | 316 | 99.12d | 0d |  |
| 318 | 12.27 | M1 Data 1 | milestone | 1h | 2003-08-03 09:00 | 2003-08-03 10:00 | 317 | 99.12d | 0d |  |
| 319 | 12.28 | M1 Data 1 | milestone | 1h | 2003-08-03 10:00 | 2003-08-03 11:00 | 318 | 99.12d | 0d |  |
| 320 | 12.29 | M1 Data 1 | milestone | 1h | 2003-08-03 11:00 | 2003-08-03 12:00 | 319 | 99.12d | 0d |  |
| 321 | 12.30 | M1 Data 1 | milestone | 1h | 2003-08-03 12:00 | 2003-08-03 13:00 | 320 | 99.12d | 0d |  |
| 322 | 12.31 | M1 Data 1 | milestone | 1h | 2003-08-03 13:00 | 2003-08-03 14:00 | 321 | 99.12d | 0d |  |
| 323 | 12.32 | M1 Data 1 | milestone | 1h | 2003-08-03 14:00 | 2003-08-03 15:00 | 322 | 99.12d | 0d |  |
| 324 | 12.33 | M1 Data 1 | milestone | 1h | 2003-08-03 15:00 | 2003-08-03 16:00 | 323 | 99.12d | 0d |  |
| 325 | 12.34 | M1 Data 1 | milestone | 1h | 2003-08-03 16:00 | 2003-08-03 17:00 | 324 | 99.12d | 0d |  |
| 326 | 12.35 | M1 Data 1 | milestone | 1h | 2003-08-03 17:00 | 2003-08-03 18:00 | 325 | 99.12d | 0d |  |
| 327 | 12.36 | M1 Data 1 | milestone | 1h | 2003-08-03 18:00 | 2003-08-03 19:00 | 326 | 99.12d | 0d |  |
| 328 | 12.37 | M1 Data 1 | milestone | 1h | 2003-08-03 19:00 | 2003-08-03 20:00 | 327 | 99.12d | 0d |  |
| 329 | 12.38 | M1 Data 1 | milestone | 1h | 2003-08-03 20:00 | 2003-08-03 21:00 | 328 | 99.12d | 0d |  |
| 330 | 12.39 | M1 Data 1 | milestone | 1h | 2003-08-03 21:00 | 2003-08-03 22:00 | 329 | 99.12d | 0d |  |
| 331 | 12.40 | M1 Data 1 | milestone | 1h | 2003-08-03 22:00 | 2003-08-03 23:00 | 330 | 99.12d | 0d |  |
| 332 | 12.41 | M1 Data 1 | milestone | 1h | 2003-08-03 23:00 | 2003-08-04 00:00 | 331 | 99.12d | 0d |  |
| 333 | 12.42 | M1 Data 1 | milestone | 1h | 2003-08-04 00:00 | 2003-08-04 01:00 | 332 | 99.12d | 0d |  |
| 334 | 12.43 | M1 Data 1 | milestone | 1h | 2003-08-04 01:00 | 2003-08-04 02:00 | 333 | 99.12d | 0d |  |
| 335 | 12.44 | M1 Data 1 | milestone | 1h | 2003-08-04 02:00 | 2003-08-04 03:00 | 334 | 99.12d | 0d |  |
| 336 | 12.45 | M1 Data 1 | milestone | 1h | 2003-08-04 03:00 | 2003-08-04 04:00 | 335 | 99.12d | 0d |  |
| 337 | 12.46 | M1 Data 1 | milestone | 1h | 2003-08-04 04:00 | 2003-08-04 05:00 | 336 | 99.12d | 0d |  |
| 338 | 12.47 | M1 Data 1 | milestone | 1h | 2003-08-04 05:00 | 2003-08-04 06:00 | 337 | 99.12d | 0d |  |
| 339 | 12.48 | M1 Data 1 | milestone | 1h | 2003-08-04 06:00 | 2003-08-04 07:00 | 338 | 99.12d | 0d |  |
| 340 | 12.49 | M1 Data 1 | milestone | 1h | 2003-08-04 07:00 | 2003-08-04 08:00 | 339 | 99.12d | 0d |  |

| ID | WBS | Task | Type | Duration | Start | Finish | Predecessors | Total slack | Free slack |
| --- | --- | --- | --- | --- | --- | --- | --- | --- | --- |
| 341 | 12.50 | M1 Data 1 | milestone | 1h | 2003-08-04 08:00 | 2003-08-04 09:00 | 340 | 99.12d | 0d |
| 342 | 12.51 | M1 Data 1 | milestone | 1h | 2003-08-04 09:00 | 2003-08-04 10:00 | 341 | 99.12d | 0d |
| 343 | 12.52 | M1 Data 1 | milestone | 1h | 2003-08-04 10:00 | 2003-08-04 11:00 | 342 | 99.12d | 0d |
| 344 | 12.53 | M1 Data 1 | milestone | 1h | 2003-08-04 11:00 | 2003-08-04 12:00 | 343 | 99.12d | 0d |
| 345 | 12.54 | M1 Data 1 | milestone | 1h | 2003-08-04 12:00 | 2003-08-04 13:00 | 344 | 99.12d | 0d |
| 346 | 12.55 | M1 Data 1 | milestone | 1h | 2003-08-04 13:00 | 2003-08-04 14:00 | 345 | 99.12d | 0d |
| 347 | 12.56 | M1 Data 1 | milestone | 1h | 2003-08-04 14:00 | 2003-08-04 15:00 | 346 | 99.12d | 0d |
| 348 | 12.57 | M1 Data 1 | milestone | 1h | 2003-08-04 15:00 | 2003-08-04 16:00 | 347 | 99.12d | 0d |
| 349 | 12.58 | M1 Data 1 | milestone | 1h | 2003-08-04 16:00 | 2003-08-04 17:00 | 348 | 99.12d | 0d |
| 350 | 12.59 | M1 Data 1 | milestone | 1h | 2003-08-04 17:00 | 2003-08-04 18:00 | 349 | 99.12d | 0d |
| 351 | 12.60 | M1 Data 1 | milestone | 1h | 2003-08-04 18:00 | 2003-08-04 19:00 | 350 | 99.12d | 0d |
| 352 | 12.61 | M1 Data 1 | milestone | 1h | 2003-08-04 19:00 | 2003-08-04 20:00 | 351 | 99.12d | 0d |
| 353 | 12.62 | M1 Data 1 | milestone | 1h | 2003-08-04 20:00 | 2003-08-04 21:00 | 352 | 99.12d | 0d |
| 354 | 12.63 | M1 Data 1 | milestone | 1h | 2003-08-04 21:00 | 2003-08-04 22:00 | 353 | 99.12d | 0d |
| 355 | 12.64 | M1 Data 1 | milestone | 1h | 2003-08-04 22:00 | 2003-08-04 23:00 | 354 | 99.12d | 0d |
| 356 | 12.65 | M1 Data 1 | milestone | 1h | 2003-08-04 23:00 | 2003-08-05 00:00 | 355 | 99.12d | 0d |
| 357 | 12.66 | M1 Data 1 | milestone | 1h | 2003-08-05 00:00 | 2003-08-05 01:00 | 356 | 99.12d | 0d |
| 358 | 12.67 | M1 Data 1 | milestone | 1h | 2003-08-05 01:00 | 2003-08-05 02:00 | 357 | 99.12d | 0d |
| 359 | 12.68 | M1 Data 1 | milestone | 1h | 2003-08-05 02:00 | 2003-08-05 03:00 | 358 | 99.12d | 0d |
| 360 | 12.69 | M1 Data 1 | milestone | 1h | 2003-08-05 03:00 | 2003-08-05 04:00 | 359 | 99.12d | 0d |
| 361 | 12.70 | M1 Data 1 | milestone | 1h | 2003-08-05 04:00 | 2003-08-05 05:00 | 360 | 99.12d | 0d |
| 362 | 12.71 | M1 Data 1 | milestone | 1h | 2003-08-05 05:00 | 2003-08-05 06:00 | 361 | 99.12d | 0d |
| 363 | 12.72 | M1 Data 1 | milestone | 1h | 2003-08-05 06:00 | 2003-08-05 07:00 | 362 | 99.12d | 0d |
| 364 | 12.73 | M1 Data 1 | milestone | 1h | 2003-08-05 07:00 | 2003-08-05 08:00 | 363 | 99.12d | 0d |
| 365 | 12.74 | M1 Data 1 | milestone | 1h | 2003-08-05 08:00 | 2003-08-05 09:00 | 364 | 99.12d | 0d |
| 366 | 12.75 | M1 Data 1 | milestone | 1h | 2003-08-05 09:00 | 2003-08-05 10:00 | 365 | 99.12d | 0d |
| 367 | 12.76 | M1 Data 1 | milestone | 1h | 2003-08-05 10:00 | 2003-08-05 11:00 | 366 | 99.12d | 0d |
| 368 | 12.77 | M1 Data 1 | milestone | 1h | 2003-08-05 11:00 | 2003-08-05 12:00 | 367 | 99.12d | 0d |
| 369 | 12.78 | M1 Data 1 | milestone | 1h | 2003-08-05 12:00 | 2003-08-05 13:00 | 368 | 99.12d | 0d |
| 370 | 12.79 | M1 Data 1 | milestone | 1h | 2003-08-05 13:00 | 2003-08-05 14:00 | 369 | 99.12d | 0d |
| 371 | 12.80 | M1 Data 1 | milestone | 1h | 2003-08-05 14:00 | 2003-08-05 15:00 | 370 | 99.12d |  |

| ID | WBS | Task | Type | Duration | Start | Finish | Total slack | Constraint |
| --- | --- | --- | --- | --- | --- | --- | --- | --- |
| 372 | 13 | **COAMPS Data** |  | 15d | 2003-08-02 15:00 | 2003-08-07 15:00 | 93.12d |  |
| 373 | 13.1 | COAMPS Data 1 | milestone | 0h | 2003-08-02 15:00 | 2003-08-02 15:00 | 108.12d | start no earlier than 2003-08-02 15:00 |
| 374 | 13.2 | COAMPS Data 2 | milestone | 0h | 2003-08-03 15:00 | 2003-08-03 15:00 | 105.12d | start no earlier than 2003-08-03 15:00 |
| 375 | 13.3 | COAMPS Data 3 | milestone | 0h | 2003-08-04 15:00 | 2003-08-04 15:00 | 102.12d | start no earlier than 2003-08-04 15:00 |
| 376 | 13.4 | COAMPS Data 4 | milestone | 0h | 2003-08-05 15:00 | 2003-08-05 15:00 | 99.12d | start no earlier than 2003-08-05 15:00 |
| 377 | 13.5 | COAMPS Data 5 | milestone | 0h | 2003-08-06 15:00 | 2003-08-06 15:00 | 96.12d | start no earlier than 2003-08-06 15:00 |
| 378 | 13.6 | COAMPS Data 6 | milestone | 0h | 2003-08-07 15:00 | 2003-08-07 15:00 | 93.12d | start no earlier than 2003-08-07 15:00 |
| 379 | 14 | **hydrography reporting** |  | 108d | 2003-08-02 16:00 | 2003-09-07 16:00 | 0d |  |
| 380 | 14.1 | hydrography reporting 1 | milestone | 0h | 2003-08-02 16:00 | 2003-08-02 16:00 | 108d | start no earlier than 2003-08-02 16:00 |
| 381 | 14.2 | hydrography reporting 2 | milestone | 0h | 2003-08-03 16:00 | 2003-08-03 16:00 | 105d | start no earlier than 2003-08-03 16:00 |
| 382 | 14.3 | hydrography reporting 3 | milestone | 0h | 2003-08-04 16:00 | 2003-08-04 16:00 | 102d | start no earlier than 2003-08-04 16:00 |
| 383 | 14.4 | hydrography reporting 4 | milestone | 0h | 2003-08-05 16:00 | 2003-08-05 16:00 | 99d | start no earlier than 2003-08-05 16:00 |
| 384 | 14.5 | hydrography reporting 5 | milestone | 0h | 2003-08-06 16:00 | 2003-08-06 16:00 | 96d | start no earlier than 2003-08-06 16:00 |
| 385 | 14.6 | hydrography reporting 6 | milestone | 0h | 2003-08-07 16:00 | 2003-08-07 16:00 | 93d | start no earlier than 2003-08-07 16:00 |
| 386 | 14.7 | hydrography reporting 7 | milestone | 0h | 2003-08-08 16:00 | 2003-08-08 16:00 | 90d | start no earlier than 2003-08-08 16:00 |
| 387 | 14.8 | hydrography reporting 8 | milestone | 0h | 2003-08-09 16:00 | 2003-08-09 16:00 | 87d | start no earlier than 2003-08-09 16:00 |
| 388 | 14.9 | hydrography reporting 9 | milestone | 0h | 2003-08-10 16:00 | 2003-08-10 16:00 | 84d | start no earlier than 2003-08-10 16:00 |
| 389 | 14.10 | hydrography reporting 10 | milestone | 0h | 2003-08-11 16:00 | 2003-08-11 16:00 | 81d | start no earlier than 2003-08-11 16:00 |
| 390 | 14.11 | hydrography reporting 11 | milestone | 0h | 2003-08-12 16:00 | 2003-08-12 16:00 | 78d | start no earlier than 2003-08-12 16:00 |
| 391 | 14.12 | hydrography reporting 12 | milestone | 0h | 2003-08-13 16:00 | 2003-08-13 16:00 | 75d | start no earlier than 2003-08-13 16:00 |
| 392 | 14.13 | hydrography reporting 13 | milestone | 0h | 2003-08-14 16:00 | 2003-08-14 16:00 | 72d | start no earlier than 2003-08-14 16:00 |
| 393 | 14.14 | hydrography reporting 14 | milestone | 0h | 2003-08-15 16:00 | 2003-08-15 16:00 | 69d | start no earlier than 2003-08-15 16:00 |
| 394 | 14.15 | hydrography reporting 15 | milestone | 0h | 2003-08-16 16:00 | 2003-08-16 16:00 | 66d | start no earlier than 2003-08-16 16:00 |
| 395 | 14.16 | hydrography reporting 16 | milestone | 0h | 2003-08-17 16:00 | 2003-08-17 16:00 | 63d | start no earlier than 2003-08-17 16:00 |
| 396 | 14.17 | hydrography reporting 17 | milestone | 0h | 2003-08-18 16:00 | 2003-08-18 16:00 | 60d | start no earlier than 2003-08-18 16:00 |
| 397 | 14.18 | hydrography reporting 18 | milestone | 0h | 2003-08-19 16:00 | 2003-08-19 16:00 | 57d | start no earlier than 2003-08-19 16:00 |
| 398 | 14.19 | hydrography reporting 19 | milestone | 0h | 2003-08-20 16:00 | 2003-08-20 16:00 | 54d | start no earlier than 2003-08-20 16:00 |
| 399 | 14.20 | hydrography reporting 20 | milestone | 0h | 2003-08-21 16:00 | 2003-08-21 16:00 | 51d | start no earlier than 2003-08-21 16:00 |
| 400 | 14.21 | hydrography reporting 21 | milestone | 0h | 2003-08-22 16:00 | 2003-08-22 16:00 | 48d | start no earlier than 2003-08-22 16:00 |
| 401 | 14.22 | hydrography reporting 22 | milestone | 0h | 2003-08-23 16:00 | 2003-08-23 16:00 | 45d | start no earlier than 2003-08-23 16:00 |
| 402 | 14.23 | hydrography reporting 23 | milestone | 0h | 2003-08-24 16:00 | 2003-08-24 16:00 | 42d | start no earlier than 2003-08-24 16:00 |
| 403 | 14.24 | hydrography reporting 24 | milestone | 0h | 2003-08-25 16:00 | 2003-08-25 16:00 | 39d | start no earlier than 2003-08-25 16:00 |
| 404 | 14.25 | hydrography reporting 25 | milestone | 0h | 2003-08-26 16:00 | 2003-08-26 16:00 | 36d | start no earlier than 2003-08-26 16:00 |
| 405 | 14.26 | hydrography reporting 26 | milestone | 0h | 2003-08-27 16:00 | 2003-08-27 16:00 | 33d | start no earlier than 2003-08-27 16:00 |
| 406 | 14.27 | hydrography reporting 27 | milestone | 0h | 2003-08-28 16:00 | 2003-08-28 16:00 | 30d | start no earlier than 2003-08-28 16:00 |
| 407 | 14.28 | hydrography reporting 28 | milestone | 0h | 2003-08-29 16:00 | 2003-08-29 16:00 | 27d | start no earlier than 2003-08-29 16:00 |
| 408 | 14.29 | hydrography reporting 29 | milestone | 0h | 2003-08-30 16:00 | 2003-08-30 16:00 | 24d | start no earlier than 2003-08-30 16:00 |
| 409 | 14.30 | hydrography reporting 30 | milestone | 0h | 2003-08-31 16:00 | 2003-08-31 16:00 | 21d | start no earlier than 2003-08-31 16:00 |
| 410 | 14.31 | hydrography reporting 31 | milestone | 0h | 2003-09-01 16:00 | 2003-09-01 16:00 | 18d | start no earlier than 2003-09-01 16:00 |
| 411 | 14.32 | hydrography reporting 32 | milestone | 0h | 2003-09-02 16:00 | 2003-09-02 16:00 | 15d | start no earlier than 2003-09-02 16:00 |
| 412 | 14.33 | hydrography reporting 33 | milestone | 0h | 2003-09-03 16:00 | 2003-09-03 16:00 | 12d | start no earlier than 2003-09-03 16:00 |
| 413 | 14.34 | hydrography reporting 34 | milestone | 0h | 2003-09-04 16:00 | 2003-09-04 16:00 | 9d | start no earlier than 2003-09-04 16:00 |
| 414 | 14.35 | hydrography reporting 35 | milestone | 0h | 2003-09-05 16:00 | 2003-09-05 16:00 | 6d | start no earlier than 2003-09-05 16:00 |
| 415 | 14.36 | hydrography reporting 36 | milestone | 0h | 2003-09-06 16:00 | 2003-09-06 16:00 | 3d | start no earlier than 2003-09-06 16:00 |
| 416 | 14.37 | hydrography reporting 37 | milestone | 0h | 2003-09-07 16:00 | 2003-09-07 16:00 | 0d | start no earlier than 2003-09-07 16:00 |
